# TFG

Schedule from MS Project, 2015-10-01 to 2015-12-02, costs in €.

## Calendars

- Estándar: Mon-Fri 09:00-13:00, 15:00-19:00; Sat-Sun off.

## Resources

| Resource | Rate |
| --- | --- |
| Daniel Taratiel | 5 |

## Schedule

| ID | Task | Type | Duration | Start | Finish | Predecessors | Total slack | Free slack | Constraint | Resources | Work | Cost |
| --- | --- | --- | --- | --- | --- | --- | --- | --- | --- | --- | --- | --- |
| 1 | Programar Modelo de dominio |  | 10d | 2015-10-01 | 2015-10-14 |  | 0d |  |  | Daniel Taratiel | 80h | 400 |
| 2 | Creación Base de Datos |  | 2d | 2015-10-15 | 2015-10-16 | 1 | 0d |  |  | Daniel Taratiel | 16h | 80 |
| 3 | Programar DAO |  | 2d | 2015-10-19 | 2015-10-20 | 1, 2 | 0d |  |  | Daniel Taratiel | 16h | 80 |
| 4 | Modelo | milestone | 0d | 2015-10-20 | 2015-10-20 | 1, 2, 3 | 30.5d |  |  |  |  |  |
| 5 | Diseño Vista Inicio |  | 1d | 2015-11-25 | 2015-11-26 | 6 | 4d | 2d |  | Daniel Taratiel | 8h | 40 |
| 6 | Programar Controlador Inicio |  | 0.5d | 2015-11-24 | 2015-11-24 | 3, 7 | 4d | 0d |  | Daniel Taratiel | 4h | 20 |
| 7 | Programar Controlador CUInicio |  | 0.5d | 2015-11-20 | 2015-11-20 | 3 | 4d | 0d |  | Daniel Taratiel | 4h | 20 |
| 8 | Diseño Vista Administrador |  | 1d | 2015-11-26 | 2015-11-27 | 9 | 3d | 1d |  | Daniel Taratiel | 8h | 40 |
| 9 | Programar Controlador Administrador |  | 0.5d | 2015-11-24 | 2015-11-24 | 3, 10, 11, 12 | 3d | 0d |  | Daniel Taratiel | 4h | 20 |
| 10 | Programar Controlador CUAltaUsuario |  | 0.5d | 2015-11-20 | 2015-11-20 | 3 | 4d | 1d |  | Daniel Taratiel | 4h | 20 |
| 11 | Programar Controlador CUModificacionUsuario |  | 0.5d | 2015-11-23 | 2015-11-23 | 3 | 3.5d | 0.5d |  | Daniel Taratiel | 4h | 20 |
| 12 | Programar Controlador CUBajaUsuario |  | 0.5d | 2015-11-23 | 2015-11-23 | 3 | 3d | 0d |  | Daniel Taratiel | 4h | 20 |
| 13 | Diseño Vista Operador |  | 1d | 2015-11-27 | 2015-11-30 | 14 | 2d | 0d |  | Daniel Taratiel | 8h | 40 |
| 14 | Programar Controlador Operador |  | 0.5d | 2015-11-25 | 2015-11-25 | 3, 15, 16, 17, 18 | 2.5d | 0d |  | Daniel Taratiel | 4h | 20 |
| 15 | Programar Controlador CUAñadirPasesPrevistos |  | 2d | 2015-11-12 | 2015-11-13 | 3 | 5d | 4d |  | Daniel Taratiel | 16h | 80 |
| 16 | Programar Controlador CUSupervisarPases |  | 1d | 2015-11-18 | 2015-11-18 | 3 | 2d | 1d |  | Daniel Taratiel | 8h | 40 |
| 17 | Programar Controlador CUObtenerProductos |  | 1d | 2015-11-19 | 2015-11-19 | 3 | 1d | 0d |  | Daniel Taratiel | 8h | 40 |
| 18 | Programar Controlador CUGrabarMedio |  | 2d | 2015-11-16 | 2015-11-17 | 3 | 3d | 2d |  | Daniel Taratiel | 16h | 80 |
| 19 | Programar Controlador SistemaDeControl |  | 2d | 2015-11-30 | 2015-12-02 | 20, 21, 22 | 0d |  | start no earlier than 2015-10-21 | Daniel Taratiel | 16h | 80 |
| 20 | Programar Controlador CUBuscarProductosNuevos |  | 8d | 2015-10-21 | 2015-10-30 | 3 | 8d |  |  | Daniel Taratiel | 64h | 320 |
| 21 | Programar Controlador CUControlarPase |  | 4d | 2015-11-02 | 2015-11-05 | 3 | 4d |  |  | Daniel Taratiel | 32h | 160 |
| 22 | Programar Controlador CUAlmacenarProductos |  | 4d | 2015-11-06 | 2015-11-11 | 3 | 0d |  |  | Daniel Taratiel | 32h | 160 |
| 23 | Vista | milestone | 0d | 2015-11-30 | 2015-11-30 | 5, 8, 13 | 2d |  |  |  |  |  |
| 24 | Controlador | milestone | 0d | 2015-12-02 | 2015-12-02 | 14, 9, 6, 19 | 0d |  |  |  |  |  |
